# proyecto1-modificado

Schedule from MS Project, 2009-09-30 to 2009-12-17.
_

## Calendars

- Estándar: Mon-Tue off; Wed 19:30-22:00; Thu 16:30-18:15; Fri 16:30-19:10; Sat-Sun off. Exceptions (off unless hours are given): 2009-10-30.
- Calendario de clase: Mon-Tue off; Wed 19:30-22:00; Thu 16:30-18:15; Fri 16:30-19:10; Sat-Sun off. Exceptions (off unless hours are given): 2009-10-30.
- Calendario de trabajo: Mon-Tue off; Wed 10:00-12:00, 19:30-22:00; Thu 10:00-12:00, 16:30-18:15; Fri 16:30-19:10; Sat-Sun off. Exceptions (off unless hours are given): 2009-10-30.

## Resources

| Resource |
| --- |
| profesor |
| técnico DPE |
| laboratorio |

## Schedule

| ID | WBS | Task | Duration | Start | Finish | Predecessors | Baseline start | Baseline finish | Baseline duration | Total slack | Free slack | Calendar | Resources | Work |
| --- | --- | --- | --- | --- | --- | --- | --- | --- | --- | --- | --- | --- | --- | --- |
| 1 | 1 | presentación | 2h | 2009-09-30 | 2009-09-30 |  | 2008-09-30 | 2008-09-30 | 1h | 0.22d | 0d | Calendario de clase | profesor; laboratorio | 2h |
| 2 | 2 | **estudios previos** | 2.75d | 2009-09-30 | 2009-10-22 |  | 2008-09-30 | 2008-10-23 | 3.12d | 0.22d |  |  |  | 32h |
| 3 | 2.1 | Repaso del PIC16F84 | 3h | 2009-09-30 | 2009-10-02 | 1 | 2008-09-30 | 2008-10-02 | 5h | 0.22d | 0d | Calendario de clase | profesor | 3h |
| 4 | 2.2 | Proteus | 4h | 2009-10-02 | 2009-10-07 | 3 | 2008-10-07 | 2008-10-09 | 4h | 0.22d | 0d | Calendario de clase | profesor; técnico DPE | 8h |
| 5 | 2.3 | práctica PIC16F84 | 3h | 2009-10-14 | 2009-10-15 | 4 | 2008-10-09 | 2008-10-14 | 4h | 0.22d | 0d | Calendario de clase | profesor | 3h |
| 6 | 2.4 | estudio del PIC16F88 | 6h | 2009-10-07 | 2009-10-14 | 4 | 2008-10-09 | 2008-10-16 | 4h | 0.59d | 0.38d | Calendario de clase | profesor | 6h |
| 7 | 2.5 | estudio de MS-Project | 2h | 2009-10-21 | 2009-10-22 | 8, 5, 6 | 2008-10-21 | 2008-10-23 | 2h | 6.55d |  | Calendario de clase | profesor | 2h |
| 8 | 2.6 | estudio de la gestión de proyectos | 4h | 2009-10-15 | 2009-10-21 | 4 | 2008-10-16 | 2008-10-21 | 4h | 6.55d | 0d | Calendario de clase | profesor | 4h |
| 9 | 2.7 | Estudio de sensores y motores | 3h | 2009-10-15 | 2009-10-21 | 6, 5 |  |  |  | 0.22d | 0d | Calendario de trabajo | técnico DPE | 3h |
| 10 | 2.8 | Estudio de robots y elección del modelo | 3h | 2009-10-15 | 2009-10-22 | 6, 5 |  |  |  | 1.75d | 0d | Calendario de trabajo | técnico DPE | 3h |
| 11 | 3 | **realización de la carrocería** | 6.65d | 2009-10-22 | 2009-12-17 |  |  |  |  | 0d |  |  |  | 20h |
| 12 | 3.1 | Montaje de la carrocería general | 5h | 2009-10-22 | 2009-10-28 | 10 |  |  |  | 3.35d | 0d | Calendario de trabajo | técnico DPE | 5h |
| 13 | 3.2 | Montaje de ruedas y motores | 2h | 2009-10-29 | 2009-10-29 | 12 |  |  |  | 3.53d | 0.34d | Calendario de trabajo | técnico DPE | 2h |
| 14 | 3.3 | Montaje de la placa de sensores | 1h | 2009-11-05 | 2009-11-11 | 21 |  |  |  | 2.26d | 0d | Calendario de trabajo | técnico DPE | 1h |
| 15 | 3.4 | Montaje con el prototipo hardware | 1h | 2009-11-11 | 2009-11-11 | 22, 12, 13, 14 |  |  |  | 2.26d | 0d | Calendario de trabajo | técnico DPE | 1h |
| 16 | 3.5 | Montaje de la placa PCB | 1h | 2009-11-27 | 2009-11-27 | 28 |  |  |  | 0d |  | Calendario de trabajo | técnico DPE | 1h |
| 17 | 3.6 | Pruebas globales | 10h | 2009-12-04 | 2009-12-17 | 16, 34 |  |  |  | 0d |  | Calendario de clase | técnico DPE; laboratorio | 10h |
| 18 | 4 | **realización del hardware** | 4.58d | 2009-10-21 | 2009-11-27 |  | 2008-10-16 | 2008-11-27 | 5.25d | 0d |  |  |  | 38h |
| 19 | 4.1 | prueba de sensores | 3h | 2009-10-21 | 2009-10-22 | 9 | 2008-10-16 | 2008-11-13 | 3.75d | 1.02d | 0d | Calendario de clase | técnico DPE; laboratorio | 3h |
| 20 | 4.2 | prueba de motores | 3h | 2009-10-28 | 2009-10-29 | 9 |  |  |  | 0d |  | Calendario de clase | técnico DPE; laboratorio | 3h |
| 21 | 4.3 | realización de la placa de sensores | 3h | 2009-10-22 | 2009-10-23 | 19 |  |  |  | 1.18d | 0d | Calendario de clase | técnico DPE; laboratorio | 3h |
| 22 | 4.4 | realización del prototipo en wrapping | 6h | 2009-11-04 | 2009-11-05 | 19, 20, 10 |  |  |  | 0.06d | 0d | Calendario de trabajo | técnico DPE | 6h |
| 23 | 4.5 | pruebas de Hardware y modificaciones | 15h | 2009-11-05 | 2009-11-19 | 22 |  |  |  | 0d |  | Calendario de clase | técnico DPE; laboratorio | 15h |
| 24 | 4.6 | **realización del circuito impreso** | 1d | 2009-11-19 | 2009-11-27 |  | 2008-11-18 | 2008-11-27 | 1.5d | 0d |  |  |  | 8h |
| 25 | 4.6.1 | diseño de la placa | 4h | 2009-11-19 | 2009-11-25 | 23 | 2008-11-18 | 2008-11-20 | 4h | 0d |  | Calendario de clase | técnico DPE | 4h |
| 26 | 4.6.2 | realización de la placa | 2h | 2009-11-25 | 2009-11-26 | 25 | 2008-11-20 | 2008-11-20 | 2h | 0d |  | Calendario de clase | técnico DPE; laboratorio | 2h |
| 27 | 4.6.3 | comprobación de la placa | 1h | 2009-11-26 | 2009-11-26 | 26 | 2008-11-20 | 2008-11-20 | 1h | 0d |  | Calendario de clase | técnico DPE; laboratorio | 1h |
| 28 | 4.6.4 | montaje de componentes | 1h | 2009-11-26 | 2009-11-27 | 27 | 2008-11-25 | 2008-11-25 | 1h | 0d |  | Calendario de clase | técnico DPE; laboratorio | 1h |

| ID | WBS | Task | Duration | Start | Finish | Predecessors | Baseline start | Baseline finish | Baseline duration | Total slack | Free slack | Calendar | Resources | Work |
| --- | --- | --- | --- | --- | --- | --- | --- | --- | --- | --- | --- | --- | --- | --- |
| 29 | 5 | **realización del software** | 2.82d | 2009-10-22 | 2009-11-18 |  | 2008-10-23 | 2008-11-11 | 2.25d | 1.51d |  |  |  |  |
| 30 | 5.1 | rutinas de prueba de sensores | 3h | 2009-10-22 | 2009-10-23 | 9, 6, 19 |  |  |  | 4.46d | 0d | Calendario de trabajo |  |  |
| 31 | 5.2 | rutinas de prueba de motores | 3h | 2009-11-04 | 2009-11-04 | 9, 6, 20 |  |  |  | 2.94d | 0d | Calendario de trabajo |  |  |
| 32 | 5.3 | rutinas de lectura de sensores | 4h | 2009-10-23 | 2009-10-28 | 21, 30 |  |  |  | 4.46d | 1.26d | Calendario de trabajo |  |  |
| 33 | 5.4 | rutinas de movimiento de motores | 4h | 2009-11-04 | 2009-11-05 | 13, 31 |  |  |  | 2.94d | 0.49d | Calendario de trabajo |  |  |
| 34 | 5.5 | movimiento del robot | 12h | 2009-11-11 | 2009-11-18 | 32, 33, 22, 15 |  |  |  | 2.26d | 1.51d | Calendario de trabajo |  |  |
| 35 | 6 | **realización de la documentación** | 2.19d | 2009-11-27 | 2009-12-17 |  | 2008-11-20 | 2008-12-09 | 2.25d | 0.06d |  |  |  | 20h |
| 36 | 6.1 | memoria descriptiva | 6h | 2009-11-27 | 2009-12-03 | 25 | 2008-11-20 | 2008-11-25 | 6h | 0.06d | 0d | Calendario de trabajo | técnico DPE | 6h |
| 37 | 6.2 | diseño de hardware | 4h | 2009-12-03 | 2009-12-04 | 36 | 2008-11-25 | 2008-11-27 | 4h | 0.06d | 0d | Calendario de trabajo | técnico DPE | 4h |
| 38 | 6.3 | diseño de software | 4h | 2009-12-09 | 2009-12-10 | 37 | 2008-12-02 | 2008-12-04 | 4h | 0.19d | 0d | Calendario de trabajo | técnico DPE | 4h |
| 39 | 6.4 | planos | 1h | 2009-12-17 | 2009-12-17 | 37 | 2008-12-02 | 2008-12-02 | 1h | 0.06d |  | Calendario de trabajo | técnico DPE | 1h |
| 40 | 6.5 | presupuesto | 1h | 2009-12-17 | 2009-12-17 | 37, 38 | 2008-12-04 | 2008-12-04 | 1h | 0.19d |  | Calendario de trabajo | técnico DPE | 1h |
| 41 | 6.6 | manual del usuario | 2h | 2009-12-16 | 2009-12-16 | 42 | 2008-12-04 | 2008-12-09 | 2h | 0.38d |  | Calendario de trabajo | técnico DPE | 2h |
| 42 | 6.7 | manual del S.A.T. | 2h | 2009-12-16 | 2009-12-16 | 37, 38 | 2008-12-04 | 2008-12-04 | 2h | 0.38d | 0d | Calendario de trabajo | técnico DPE | 2h |
